# Brochure

Schedule from MS Project, 2024-04-23 to 2024-06-07, status date 2024-05-30, costs in €, A marks actual dates.

## Calendars

- Standaard: Mon-Fri 08:00-12:00, 13:00-17:00; Sat-Sun off. Exceptions (off unless hours are given): 2024-05-01 (1 mei).

## Resources

| Resource | Rate |
| --- | --- |
| Marketing mgr | 100 |
| Reviewer | 70 |
| Vertaler NL | 70 |
| Vertaler EN | 70 |
| Marketing assistent | 60 |
| Drukkerij |  |
| Levering |  |

## Schedule

| ID | WBS | Task | Type | Duration | Start | Finish | Predecessors | Complete | Remaining | Baseline start | Baseline finish | Baseline duration | Total slack | Deadline | Resources | Work | Actual work | Cost | Baseline cost | Actual cost |
| --- | --- | --- | --- | --- | --- | --- | --- | --- | --- | --- | --- | --- | --- | --- | --- | --- | --- | --- | --- | --- |
| 1 | 1 | Start | milestone | 0d | 2024-04-23 | 2024-04-23 |  |  |  | 2024-04-23 | 2024-04-23 | 0d | 30.75d |  |  |  |  |  |  |  |
| 2 | 2 | **Tekst** |  | 24.5d | 2024-04-23 A | 2024-05-28 A |  | 100% |  | 2024-04-23 | 2024-05-17 | 17.5d |  |  |  | 168h | 168h | 13,200 | 9,720 | 13,200 |
| 3 | 2.1 | Vergadering |  | 4h | 2024-04-23 A | 2024-04-23 A | 1 | 100% |  | 2024-04-23 | 2024-04-23 | 4h |  |  |  |  |  |  |  |  |
| 4 | 2.2 | Schrijf tekst in FR |  | 6d | 2024-04-23 A | 2024-05-02 A | 3 | 100% |  | 2024-04-23 | 2024-04-30 | 5d |  |  | Marketing mgr | 48h | 48h | 4,800 | 3,000 | 4,800 |
| 5 | 2.3 | Reviseer tekst |  | 1d | 2024-05-06 A | 2024-05-06 A | 4 | 100% |  | 2024-04-30 | 2024-05-03 | 2d |  |  | Reviewer | 8h | 8h | 560 | 1,120 | 560 |
| 6 | 2.4 | Vertaal naar NL |  | 6d | 2024-05-07 A | 2024-05-22 A | 5 | 100% |  | 2024-05-06 | 2024-05-17 | 5d |  |  | Vertaler NL | 48h | 48h | 3,360 | 2,800 | 3,360 |
| 7 | 2.5 | Vertaal naal EN |  | 8d | 2024-05-07 A | 2024-05-28 A | 5 | 100% |  | 2024-05-06 | 2024-05-17 | 5d |  |  | Vertaler EN | 64h | 64h | 4,480 | 2,800 | 4,480 |
| 8 | 3 | **Logistiek** |  | 15d | 2024-04-23 A | 2024-05-15 A |  | 100% |  | 2024-04-23 | 2024-05-22 | 20d |  |  |  | 30.4h | 30.4h | 2,784 | 5,280 | 2,784 |
| 9 | 3.1 | Afbeeldingen kiezen en verzamelen |  | 3w | 2024-04-23 A | 2024-05-15 A | 3 | 100% |  | 2024-04-23 | 2024-05-15 | 3w |  |  | Marketing mgr [20%] | 24h | 24h | 2,400 | 2,400 | 2,400 |
| 10 | 3.2 | Naam contact op met drukkerij |  | 0.4w | 2024-05-02 A | 2024-05-06 A | 4 | 100% |  | 2024-04-30 | 2024-05-22 | 3w |  |  | Marketing assistent [40%] | 6.4h | 6.4h | 384 | 2,880 | 384 |
| 11 | 4 | **Compilatie** |  | 11d | 2024-05-15 A | 2024-05-30 |  | 64% | 4d | 2024-05-15 | 2024-05-28 | 9d | 0d |  |  | 35.2h | 22.4h | 2,640 | 2,160 | 1,680 |
| 12 | 4.1 | Stel brochure samen in FR |  | 7d | 2024-05-15 A | 2024-05-24 A | 9, 5 | 100% |  | 2024-05-15 | 2024-05-22 | 5d |  |  | Marketing assistent [25%]; Marketing mgr [15%] | 22.4h | 22.4h | 1,680 | 1,200 | 1,680 |
| 13 | 4.2 | Stel brochure samen in NL |  | 2d | 2024-05-24 | 2024-05-28 | 12, 6 |  |  | 2024-05-22 | 2024-05-24 | 2d | 0d |  | Marketing assistent [25%]; Marketing mgr [15%] | 6.4h |  | 480 | 480 |  |
| 14 | 4.3 | Stel brochure samen in EN |  | 2d | 2024-05-28 | 2024-05-30 | 13, 7 |  |  | 2024-05-24 | 2024-05-28 | 2d | 0d |  | Marketing assistent [25%]; Marketing mgr [15%] | 6.4h |  | 480 | 480 |  |
| 15 | 5 | **Drukwerk** |  | 6.25d | 2024-05-30 | 2024-06-07 |  |  |  | 2024-05-28 | 2024-06-05 | 6.25d | 0d |  |  | 4h |  | 2,520 | 2,520 |  |
| 16 | 5.1 | Testbrochure afdrukken |  | 1d | 2024-05-30 | 2024-05-31 | 14, 10 |  |  | 2024-05-28 | 2024-05-29 | 1d | 0d |  |  |  |  |  |  |  |
| 17 | 5.2 | test afdrukken - meeting |  | 2h | 2024-05-31 | 2024-05-31 | 16 |  |  | 2024-05-29 | 2024-05-29 | 2h | 0d |  | Marketing mgr; Marketing assistent; Drukkerij [0.1%] | 4h |  | 520 | 520 |  |
| 18 | 5.3 | Alle brochures afdrukken |  | 5d | 2024-05-31 | 2024-06-07 | 17 |  |  | 2024-05-29 | 2024-06-05 | 5d | 0d |  | Drukkerij [0.1%] |  |  | 2,000 | 2,000 |  |
| 19 | 6 | Brochure beschikbaar | milestone | 0d | 2024-06-07 | 2024-06-07 | 18 |  |  | 2024-06-05 | 2024-06-05 | 0d | 0d | 2024-06-14 | Levering |  |  | 100 | 100 |  |
