# Brochure

Schedule from MS Project, 2024-04-23 to 2024-06-05, status date 2024-05-30, costs in €.

## Calendars

- Standaard: Mon-Fri 08:00-12:00, 13:00-17:00; Sat-Sun off. Exceptions (off unless hours are given): 2024-05-01 (1 mei).

## Resources

| Resource | Rate |
| --- | --- |
| Marketing mgr | 100 |
| Reviewer | 70 |
| Vertaler NL | 70 |
| Vertaler EN | 70 |
| Marketing assistent | 60 |
| Drukkerij |  |
| Levering |  |

## Schedule

| ID | WBS | Task | Type | Duration | Start | Finish | Predecessors | Baseline start | Baseline finish | Baseline duration | Total slack | Free slack | Deadline | Resources | Work | Cost | Baseline cost |
| --- | --- | --- | --- | --- | --- | --- | --- | --- | --- | --- | --- | --- | --- | --- | --- | --- | --- |
| 1 | 1 | Start | milestone | 0d | 2024-04-23 | 2024-04-23 |  | 2024-04-23 | 2024-04-23 | 0d | 0d |  |  |  |  |  |  |
| 2 | 2 | **Tekst** |  | 17.5d | 2024-04-23 | 2024-05-17 |  | 2024-04-23 | 2024-05-17 | 17.5d | 0d |  |  |  | 126h | 9,720 | 9,720 |
| 3 | 2.1 | Vergadering |  | 4h | 2024-04-23 | 2024-04-23 | 1 | 2024-04-23 | 2024-04-23 | 4h | 0d |  |  |  |  |  |  |
| 4 | 2.2 | Schrijf tekst in FR |  | 5d | 2024-04-23 | 2024-04-30 | 3 | 2024-04-23 | 2024-04-30 | 5d | 3.5d | 0d |  | Marketing mgr | 30h | 3,000 | 3,000 |
| 5 | 2.3 | Reviseer tekst |  | 2d | 2024-04-30 | 2024-05-03 | 4 | 2024-04-30 | 2024-05-03 | 2d | 3.5d | 0.5d |  | Reviewer | 16h | 1,120 | 1,120 |
| 6 | 2.4 | Vertaal naar NL |  | 5d | 2024-05-06 | 2024-05-17 | 5 | 2024-05-06 | 2024-05-17 | 5d | 3d |  |  | Vertaler NL | 40h | 2,800 | 2,800 |
| 7 | 2.5 | Vertaal naal EN |  | 5d | 2024-05-06 | 2024-05-17 | 5 | 2024-05-06 | 2024-05-17 | 5d | 5d |  |  | Vertaler EN | 40h | 2,800 | 2,800 |
| 8 | 3 | **Logistiek** |  | 20d | 2024-04-23 | 2024-05-22 |  | 2024-04-23 | 2024-05-22 | 20d | 0d |  |  |  | 72h | 5,280 | 5,280 |
| 9 | 3.1 | Afbeeldingen kiezen en verzamelen |  | 3w | 2024-04-23 | 2024-05-15 | 3 | 2024-04-23 | 2024-05-15 | 3w | 0d |  |  | Marketing mgr [20%] | 24h | 2,400 | 2,400 |
| 10 | 3.2 | Naam contact op met drukkerij |  | 3w | 2024-04-30 | 2024-05-22 | 4 | 2024-04-30 | 2024-05-22 | 3w | 4d |  |  | Marketing assistent [40%] | 48h | 2,880 | 2,880 |
| 11 | 4 | **Compilatie** |  | 9d | 2024-05-15 | 2024-05-28 |  | 2024-05-15 | 2024-05-28 | 9d | 0d |  |  |  | 28.8h | 2,160 | 2,160 |
| 12 | 4.1 | Stel brochure samen in FR |  | 5d | 2024-05-15 | 2024-05-22 | 9, 5 | 2024-05-15 | 2024-05-22 | 5d | 0d |  |  | Marketing assistent [25%]; Marketing mgr [15%] | 16h | 1,200 | 1,200 |
| 13 | 4.2 | Stel brochure samen in NL |  | 2d | 2024-05-22 | 2024-05-24 | 12, 6 | 2024-05-22 | 2024-05-24 | 2d | 0d |  |  | Marketing assistent [25%]; Marketing mgr [15%] | 6.4h | 480 | 480 |
| 14 | 4.3 | Stel brochure samen in EN |  | 2d | 2024-05-24 | 2024-05-28 | 13, 7 | 2024-05-24 | 2024-05-28 | 2d | 0d |  |  | Marketing assistent [25%]; Marketing mgr [15%] | 6.4h | 480 | 480 |
| 15 | 5 | **Drukwerk** |  | 6.25d | 2024-05-28 | 2024-06-05 |  | 2024-05-28 | 2024-06-05 | 6.25d | 0d |  |  |  | 4h | 2,520 | 2,520 |
| 16 | 5.1 | Testbrochure afdrukken |  | 1d | 2024-05-28 | 2024-05-29 | 14, 10 | 2024-05-28 | 2024-05-29 | 1d | 0d |  |  |  |  |  |  |
| 17 | 5.2 | test afdrukken - meeting |  | 2h | 2024-05-29 | 2024-05-29 | 16 | 2024-05-29 | 2024-05-29 | 2h | 0d |  |  | Marketing mgr; Marketing assistent; Drukkerij [0.1%] | 4h | 520 | 520 |
| 18 | 5.3 | Alle brochures afdrukken |  | 5d | 2024-05-29 | 2024-06-05 | 17 | 2024-05-29 | 2024-06-05 | 5d | 0d |  |  | Drukkerij [0.1%] |  | 2,000 | 2,000 |
| 19 | 6 | Brochure beschikbaar | milestone | 0d | 2024-06-05 | 2024-06-05 | 18 | 2024-06-05 | 2024-06-05 | 0d | 0d |  | 2024-06-14 | Levering |  | 100 | 100 |
