# Decoratie Feestzaal

Schedule from MS Project, 2024-09-02 to 2024-10-14, status date 2024-04-30, costs in €.

## Calendars

- Standaard: Mon-Fri 08:00-12:00, 13:00-17:00; Sat-Sun off.

## Resources

| Resource | Unit | Rate |
| --- | --- | --- |
| Decorator |  | 62.5 |
| Schilder |  | 40 |
| Tapijt bekleder |  | 50 |
| Papier | Meter | 10 |
| Tapijt | Meter | 100 |
| verf | Liter | 20 |

## Schedule

| ID | WBS | Task | Type | Duration | Start | Finish | Predecessors | Baseline start | Baseline finish | Baseline duration | Total slack | Free slack | Resources | Work | Cost | Baseline cost |
| --- | --- | --- | --- | --- | --- | --- | --- | --- | --- | --- | --- | --- | --- | --- | --- | --- |
| 1 | 1 | Planning |  | 2w | 2024-09-02 | 2024-09-13 |  |  |  |  | 0d |  |  |  |  |  |
| 2 | 2 | Begin | milestone | 0d | 2024-09-13 | 2024-09-13 | 1 | 2024-04-22 | 2024-04-22 | 0d | 0d |  |  |  |  |  |
| 3 | 3 | **Research en keuzes** |  | 8d | 2024-09-16 | 2024-09-25 |  | 2024-04-22 | 2024-05-01 | 8d | 0d |  |  | 29.2h | 1,564 | 1,564 |
| 4 | 3.1 | Papier keuze |  | 5d | 2024-09-16 | 2024-09-20 | 2 | 2024-04-22 | 2024-04-26 | 5d | 0d |  | Schilder [25%]; Decorator [20%] | 18h | 900 | 900 |
| 5 | 3.2 | Verf keuze |  | 1d | 2024-09-25 | 2024-09-25 | 6 | 2024-05-01 | 2024-05-01 | 1d | 0d |  | Decorator [20%]; Schilder [20%] | 3.2h | 164 | 164 |
| 6 | 3.3 | Tapijt keuze |  | 2d | 2024-09-23 | 2024-09-24 | 4 | 2024-04-29 | 2024-04-30 | 2d | 0d |  | Decorator [50%] | 8h | 500 | 500 |
| 7 | 4 | **Bestelllingen & goedkeuring** |  | 9d | 2024-09-23 | 2024-10-03 |  | 2024-04-22 | 2024-05-09 | 14d | 3d |  |  |  |  | 9,400 |
| 8 | 4.1 | Papierbenodigdheden |  | 8d | 2024-09-23 | 2024-10-02 | 4 | 2024-04-29 | 2024-05-08 | 8d | 4d |  |  |  |  | 4,000 |
| 9 | 4.2 | Tapijt |  | 1d | 2024-09-25 | 2024-09-25 | 6 | 2024-05-01 | 2024-05-01 | 1d | 11d |  |  |  |  | 3,000 |
| 10 | 4.3 | Schilderbenodigdheden |  | 6d | 2024-09-26 | 2024-10-03 | 5 | 2024-05-02 | 2024-05-09 | 6d | 0d |  |  |  |  | 2,400 |
| 11 | 4.4 | Gereedschappen |  | 1d | 2024-09-26 | 2024-09-26 | 2, 10SS | 2024-04-22 | 2024-04-22 | 1d | 4d | 0d |  |  |  |  |
| 12 | 5 | **Voorbereiding** |  | 5d | 2024-09-27 | 2024-10-03 |  | 2024-04-24 | 2024-04-30 | 5d | 4d |  |  | 36h | 1,660 | 1,480 |
| 13 | 5.1 | Verwijderen papier |  | 1d | 2024-09-27 | 2024-09-27 | 11, 21 | 2024-04-24 | 2024-04-24 | 1d | 4d | 0d | Decorator | 8h | 500 | 320 |
| 14 | 5.2 | Muren voorbereiden |  | 3d | 2024-09-30 | 2024-10-02 | 13 | 2024-04-25 | 2024-04-29 | 3d | 7d | 0d | Schilder | 24h | 960 | 960 |
| 15 | 5.3 | Tapijt verwijderen |  | 1d | 2024-10-03 | 2024-10-03 | 14 | 2024-04-30 | 2024-04-30 | 1d | 7d |  | Tapijt bekleder [50%] | 4h | 200 | 200 |
| 16 | 6 | **Uitvoering** |  | 6d | 2024-10-04 | 2024-10-11 |  | 2024-05-10 | 2024-05-17 | 6d | 0d |  |  | 44h | 12,460 | 1,800 |
| 17 | 6.1 | Plakken papier |  | 2d | 2024-10-09 | 2024-10-10 | 18, 8 | 2024-05-15 | 2024-05-16 | 2d | 0d |  | Papier [12.5 Meter]; Decorator | 16h | 3,000 | 640 |
| 18 | 6.2 | Verven |  | 3d | 2024-10-04 | 2024-10-08 | 10, 13 | 2024-05-10 | 2024-05-14 | 3d | 0d |  | Schilder; verf [0.62 Liter] | 24h | 1,260 | 960 |
| 19 | 6.3 | Tapijt leggen |  | 1d | 2024-10-11 | 2024-10-11 | 17, 9 | 2024-05-17 | 2024-05-17 | 1d | 0d |  | Tapijt bekleder [50%]; Tapijt [10 Meter] | 4h | 8,200 | 200 |
| 20 | 7 | **Verhuis** |  | 21d | 2024-09-16 | 2024-10-14 |  | 2024-04-22 | 2024-05-21 | 22d | 0d |  |  | 8h | 500 | 1,000 |
| 21 | 7.1 | Meubels verplaatsen |  | 1d | 2024-09-16 | 2024-09-16 | 2 | 2024-04-22 | 2024-04-23 | 2d | 12d | 0d | Decorator [50%] | 4h | 250 | 500 |
| 22 | 7.2 | Herinrichting |  | 1d | 2024-10-14 | 2024-10-14 | 19 | 2024-05-20 | 2024-05-21 | 2d | 0d |  | Decorator [50%] | 4h | 250 | 500 |
| 23 | 8 | Einde | milestone | 0d | 2024-10-14 | 2024-10-14 | 22 | 2024-05-21 | 2024-05-21 | 0d | 0d |  |  |  |  |  |
